# Renoviranje-kuće

Schedule from MS Project, 2004-05-03 to 2004-06-16, 10 hours a day, costs in Din..
Fakultet Organizacionih Nauka

## Calendars

- Bisera1: Mon-Fri 08:00-12:00, 13:00-17:00; Sat-Sun off. Exceptions (off unless hours are given): 2004-05-03 to 2004-05-08 07:00-17:00, 2004-05-09, 2004-05-10 to 2004-05-15 07:00-17:00, 2004-05-16, 2004-05-17 to 2004-05-22 07:00-17:00, 2004-05-23, 2004-05-24 to 2004-05-29 07:00-17:00, 2004-05-30, 2004-05-31 to 2004-06-05 07:00-17:00, 2004-06-06, 2004-06-07 to 2004-06-12 07:00-17:00, 2004-06-13, 2004-06-14 to 2004-06-19 07:00-17:00.

## Resources

| Resource | Unit | Rate |
| --- | --- | --- |
| Radnici za fizičke poslove |  | 140 |
| Majstor za krečenje |  | 546 |
| Pomoćnik majstora za krečenje |  | 140 |
| Majstor za gletovanje |  | 800 |
| Pomoćnik majstora za gletovanje |  | 140 |
| Majstor za pločice |  | 800 |
| Pomoćnik majstora za pločice |  | 140 |
| Parket | 0 | 1000 |
| Lepak za parket |  | 500 |
| Lak za parket |  | 500 |
| Glet masa |  | 350 |
| Kreč |  | 50 |
| Podne pločice |  | 1300 |
| Zidne pločice |  | 1150 |
| Masa za fuge |  | 35 |
| Cement |  |  |
| Pesak |  |  |
| Majstor za parket |  | 800 |
| Pomoćnik majstora za parket |  | 140 |

## Schedule

| ID | WBS | Task | Type | Duration | Start | Finish | Predecessors | Baseline start | Baseline finish | Baseline duration | Total slack | Free slack | Constraint | Resources | Work | Cost | Baseline cost |
| --- | --- | --- | --- | --- | --- | --- | --- | --- | --- | --- | --- | --- | --- | --- | --- | --- | --- |
| 1 | 35 | Početak izgradnje | milestone | 0d | 2004-05-03 | 2004-05-03 |  |  |  |  | 0d |  |  |  |  |  |  |
| 2 | 13 | Rašćišćavanje kuće |  | 2d | 2004-05-03 | 2004-05-04 | 1 | 2004-05-03 | 2004-05-04 | 2d | 0d |  | start no earlier than 2004-05-03 | Radnici za fizičke poslove [200%] | 40h | 5,600 | 5,600 |
| 3 | 1 | Vađenje brodskog poda |  | 2d | 2004-05-05 | 2004-05-06 | 2 | 2004-05-05 | 2004-05-06 | 2d | 8.3d | 0d | start no earlier than 2004-05-03 | Radnici za fizičke poslove [200%] | 40h | 5,600 | 5,600 |
| 4 | 2 | Ravnanje poda |  | 1d | 2004-05-07 | 2004-05-07 | 3 | 2004-05-07 | 2004-05-07 | 1d | 8.3d | 0d |  | Radnici za fizičke poslove | 10h | 1,400 | 1,400 |
| 5 | 3 | Ugradnja parketa |  | 5d | 2004-05-08 | 2004-05-13 | 3, 4 | 2004-05-08 | 2004-05-13 | 5d | 19.3d | 0d |  | Parket [100 0]; Lepak za parket [10000%]; Lak za parket [10000%]; Majstor za parket; Pomoćnik majstora za parket | 100h | 247,000 | 247,000 |
| 6 | 4 | Hoblovanje |  | 2d | 2004-05-14 | 2004-05-15 | 5 | 2004-05-14 | 2004-05-15 | 2d | 19.3d | 0d |  | Majstor za parket; Pomoćnik majstora za parket | 40h | 18,800 | 18,800 |
| 7 | 5 | Lakiranje parketa I put |  | 2d | 2004-05-17 | 2004-05-18 | 6 | 2004-05-17 | 2004-05-18 | 2d | 19.3d | 0d |  | Lak za parket; Majstor za parket; Pomoćnik majstora za parket | 40h | 19,300 | 19,300 |
| 8 | 6 | Lakiranje parketa II put |  | 2d | 2004-05-21 | 2004-05-22 | 7FS+2d | 2004-05-21 | 2004-05-22 | 2d | 19.3d |  |  |  |  |  |  |
| 9 | 7 | Gletovanje |  | 10d | 2004-05-05 | 2004-05-15 | 2 | 2004-05-05 | 2004-05-15 | 10d | 0d |  | start no earlier than 2004-05-03 | Majstor za gletovanje; Pomoćnik majstora za gletovanje; Glet masa | 200h | 94,350 | 94,350 |
| 10 | 8 | Krečenje I put |  | 3d | 2004-05-22 | 2004-05-25 | 9FS+5d | 2004-05-22 | 2004-05-25 | 3d | 0d |  |  | Majstor za krečenje; Pomoćnik majstora za krečenje; Kreč | 60h | 20,630 | 20,630 |
| 11 | 9 | Krečenje II put |  | 16.3d | 2004-05-27 | 2004-06-15 | 10FS+1d | 2004-05-27 | 2004-06-15 | 16.3d | 0d |  |  | Majstor za krečenje; Pomoćnik majstora za krečenje; Kreč | 326h | 111,868 | 111,868 |
| 12 | 33 | **Kupatilo** |  | 12d | 2004-05-08 | 2004-05-21 | 2, 4 | 2004-05-08 | 2004-05-21 | 12d | 8.3d | 0d |  |  | 190h | 331,070 | 88,370 |
| 13 | 33.1 | Skidanje starih pločica |  | 1d | 2004-05-08 | 2004-05-08 | 2 | 2004-05-08 | 2004-05-08 | 1d | 8.3d | 0d |  | Radnici za fizičke poslove | 10h | 1,400 | 1,400 |
| 14 | 33.2 | Ugradnja zidnih pločica |  | 6d | 2004-05-10 | 2004-05-15 | 13 | 2004-05-10 | 2004-05-15 | 6d | 8.3d | 0d |  | Majstor za pločice; Pomoćnik majstora za pločice; Zidne pločice [10000%]; Masa za fuge; Cement; Pesak | 120h | 171,435 | 57,585 |
| 15 | 33.3 | Ugradnja podnih pločica |  | 3d | 2004-05-19 | 2004-05-21 | 14FS+2d | 2004-05-19 | 2004-05-21 | 3d | 8.3d |  |  | Majstor za pločice; Pomoćnik majstora za pločice; Podne pločice [10000%]; Masa za fuge; Cement; Pesak | 60h | 158,235 | 29,385 |
| 16 | 20 | **Kuhinja** |  | 12d | 2004-05-22 | 2004-06-04 | 12 | 2004-05-22 | 2004-06-04 | 12d | 8.3d |  |  |  | 190h | 88,520 | 88,520 |
| 17 | 20.14 | Skidanje starih pločica kuhinja |  | 1d | 2004-05-22 | 2004-05-22 | 2 | 2004-05-22 | 2004-05-22 | 1d | 8.3d | 0d |  | Radnici za fizičke poslove | 10h | 1,400 | 1,400 |
| 18 | 20.15 | Ugradnja zidnih pločica kuhinja |  | 6d | 2004-05-24 | 2004-05-29 | 17 | 2004-05-24 | 2004-05-29 | 6d | 8.3d | 0d |  | Majstor za pločice; Pomoćnik majstora za pločice; Zidne pločice; Masa za fuge; Cement; Pesak | 120h | 57,585 | 57,585 |
| 19 | 20.16 | Ugradnja podnih pločica kuhinja |  | 3d | 2004-06-02 | 2004-06-04 | 18FS+2d | 2004-06-02 | 2004-06-04 | 3d | 8.3d |  |  | Majstor za pločice; Pomoćnik majstora za pločice; Podne pločice; Masa za fuge; Cement; Pesak | 60h | 29,535 | 29,535 |
| 20 | 34 | Kontrola izvrsenih radova |  | 1d | 2004-06-15 | 2004-06-16 | 4, 8, 11, 19, 15 | 2004-06-15 | 2004-06-16 | 1d? | 0d |  |  |  |  |  |  |
| 21 | 36 | Kraj | milestone | 0d | 2004-06-16 | 2004-06-16 | 20 |  |  |  | 0d |  |  |  |  |  |  |
